# Ijungimo programos_tipinis grafikas_I etapas (gc)

Schedule from MS Project, 2019-03-12 to 2019-06-18.

## Calendars

- Standard: Mon-Fri 08:00-12:00, 13:00-17:00; Sat-Sun off. Exceptions (off unless hours are given): 2019-05-01 (Tarptautine darbininku diena).

## Schedule

| ID | WBS | Task | Type | Duration | Start | Finish | Predecessors | Total slack | Free slack | Constraint |
| --- | --- | --- | --- | --- | --- | --- | --- | --- | --- | --- |
| 1 | 1 | Naujai pastatytų/rekonstruotų įrenginių (dalies įrenginių), kuriuos planuojama įjungti į perdavimo tinklą, statyba. Visos būtinos dokumentacijos parengiamasis etapas(Rangovas) | milestone | 0d | 2019-03-12 | 2019-03-12 |  | 54d | 0d |  |
| 2 | 2 | Įrenginių testavimas bandymai objekte ir/ar tarp skirtingų objektų (pasiruošimas kompleksiniams bandymas) (3-5d.d.) |  | 5d? | 2019-03-12 | 2019-03-18 | 1 | 54d |  |  |
| 3 | 3 | DVS (SCADA/EMS) parengiamieji darbai kompleksiniams bandymams (DVS realaus laiko displėjų parengimas, DVS vystymo sistemos konfigūravimas (3-5 d.d. priklauso nuo apimties, kiekvieno projekto metu derinama atskirai)) |  | 5d? | 2019-03-12 | 2019-03-18 |  | 0d |  | start no earlier than 2019-03-12 |
| 4 | 4 | Įrenginių kompleksiniai bandymai su PSO SCADA ( 7-14 d.d. (priklauso nuo apimties, kiekvieno projekto metu derinama atskirai)) |  | 14d? | 2019-03-19 | 2019-04-05 | 3 | 0d |  |  |
| 5 | 5 | Įrenginių kompleksiniai bandymai atlikti | milestone | 0d | 2019-04-05 | 2019-04-05 | 4 | 0d |  |  |
| 6 | 6 | **Visos būtinos dokumentacijos įrenginių įjungimui pateikimas PSO suderinimui (1 d.d.)** |  | 1d | 2019-04-08 | 2019-04-08 | 5 | 0d |  |  |
| 7 | 6.1 | Įrenginių pasai |  | 1d | 2019-04-08 | 2019-04-08 |  | 0d |  | finish no earlier than 2019-03-12 |
| 8 | 6.2 | Tikrinimo protokolai (pirminė, antrinė, ryšių ir kt. dalys) |  | 1d | 2019-04-08 | 2019-04-08 |  | 0d |  |  |
| 9 | 6.3 | Darbo projektas su žyma „Taip pastatyta“ |  | 1d | 2019-04-08 | 2019-04-08 |  | 0d |  |  |
| 10 | 6.4 | Operatyvinio valdymo bei eksploatavimo instrukcijos (pirminė, antrinė, ryšių ir kt. dalys) |  | 1d | 2019-04-08 | 2019-04-08 |  | 0d |  |  |
| 11 | 6.5 | Tipiniai perjungimo lapeliai ir/ar programos |  | 1d | 2019-04-08 | 2019-04-08 |  | 0d |  |  |
| 12 | 6.6 | Galutiniai signalų sąrašai (teleinformacijos redaguojamame EXEL formate sąrašas) (pasirašytas protokolas) |  | 1d | 2019-04-08 | 2019-04-08 |  | 0d |  |  |
| 13 | 7 | **Visos būtinos dokumentacijos įrenginių įjungimui suderinimas. Iteracija 1 (punktai vykdomi lygiagrečiai, per 5-10 d.d.)** |  | 10d | 2019-04-09 | 2019-04-22 | 6 | 0d |  |  |
| 14 | 7.1 | Įrenginių pasai (5-10 d.d.) |  | 10d | 2019-04-09 | 2019-04-22 |  | 0d |  |  |
| 15 | 7.2 | Tikrinimo protokolai (pirminė, antrinė, ryšių ir kt. dalys) (5-10 d.d.) |  | 10d | 2019-04-09 | 2019-04-22 |  | 0d |  |  |
| 16 | 7.3 | Darbo projektas su žyma „Taip pastatyta“ (5-10 d.d.) |  | 10d | 2019-04-09 | 2019-04-22 |  | 0d |  |  |
| 17 | 7.4 | Operatyvinio valdymo bei eksploatavimo instrukcijos (pirminė, antrinė, ryšių ir kt. dalys) (5-10 d.d.) |  | 10d | 2019-04-09 | 2019-04-22 |  | 0d |  |  |
| 18 | 7.5 | Tipiniai perjungimo lapeliai ir/ar programos (5-10 d.d. |  | 10d | 2019-04-09 | 2019-04-22 |  | 0d |  |  |
| 19 | 7.6 | Galutiniai signalų sąrašai (teleinformacijos redaguojamame EXEL formate sąrašas) (5-10 d.d.) |  | 10d | 2019-04-09 | 2019-04-22 |  | 0d |  |  |
| 20 | 8 | Visos būtinos dokumentacijos įrenginių įjungimui koregavimas (rangovas) |  | 5d | 2019-04-23 | 2019-04-29 | 13 | 0d |  |  |
| 21 | 9 | **Visos būtinos dokumentacijos įrenginių įjungimui suderinimas. Iteracija 2 (punktai vykdomi lygiagrečiai, per 3-5 d.d.)** |  | 5d | 2019-04-30 | 2019-05-07 | 20 | 0d |  |  |
| 22 | 9.1 | Įrenginių pasai (3-5 d.d.) |  | 5d | 2019-04-30 | 2019-05-07 |  | 0d |  |  |
| 23 | 9.2 | Tikrinimo protokolai (pirminė, antrinė, ryšių ir kt. dalys) (3-5 d.d.) |  | 5d | 2019-04-30 | 2019-05-07 |  | 0d |  |  |
| 24 | 9.3 | Darbo projektas su žyma „Taip pastatyta“ (3-5 d.d.) |  | 5d | 2019-04-30 | 2019-05-07 |  | 0d |  |  |
| 25 | 9.4 | Operatyvinio valdymo bei eksploatavimo instrukcijos (pirminė, antrinė, ryšių ir kt. dalys) (3-5 d.d.) |  | 5d | 2019-04-30 | 2019-05-07 |  | 0d |  |  |
| 26 | 9.5 | Tipiniai perjungimo lapeliai ir/ar programos (3-5 d.d.) |  | 5d | 2019-04-30 | 2019-05-07 |  | 0d |  |  |
| 27 | 9.6 | Galutiniai signalų sąrašai (teleinformacijos redaguojamame EXEL formate bei, susijusios darbo projekto bylos pdf formate pateikimas) (3-5 d.d.) |  | 5d | 2019-04-30 | 2019-05-07 |  | 0d |  |  |
| 28 | 10 | Visos būtinos dokumentacijos įrenginių įjungimui patvirtinimas/vizavimas (1-2 d.d.) |  | 2d | 2019-05-08 | 2019-05-09 | 21 | 17d | 0d |  |
| 29 | 11 | Visa būtina dokumentacija pateikta | milestone | 0d | 2019-05-09 | 2019-05-09 | 28 | 17d | 0d |  |

| ID | WBS | Task | Type | Duration | Start | Finish | Predecessors | Total slack |
| --- | --- | --- | --- | --- | --- | --- | --- | --- |
| 30 | 12 | **DVS (SCADA/EMS) baigiamieji etapo darbai (punktai vykdomi lygiagrečiai, per 5-7 d.d. priklauso nuo apimties, kiekvieno projekto metu derinama atskirai))** |  | 7d? | 2019-05-10 | 2019-05-20 | 29 | 17d |
| 31 | 12.1 | Konfigūracijos perkėlimas iš vystymo DVS į darbinę DVS (1 d.d.) |  | 1d? | 2019-05-10 | 2019-05-10 |  | 23d |
| 32 | 12.2 | Skaičiuojamųjų matavimų sukonfigūravimas DVS (1-3 d.d.) |  | 3d? | 2019-05-10 | 2019-05-14 |  | 21d |
| 33 | 12.3 | DVS realaus laiko displėjų parengimo užbaigimas (5-7 d.d.) |  | 7d? | 2019-05-10 | 2019-05-20 |  | 17d |
| 34 | 12.4 | DVS teisių koregavimas (jeigu įtraukiamas naujas objektas) (1-3 d.d.) |  | 3d? | 2019-05-10 | 2019-05-14 |  | 21d |
| 35 | 12.5 | TSM modelio keitimas (dėl I etapo) |  | 2d? | 2019-05-10 | 2019-05-13 |  | 22d |
| 36 | 13 | Įjungimo programos parengimas (atsakingas Rangovas) |  | 5d | 2019-05-08 | 2019-05-14 | 21 | 0d |
| 37 | 14 | Įjungimo programos derinimas su PSO RAA bei SVC atstovais, jei reikia – ir su AB ESO atstovais (5-10 d.d.) |  | 10d | 2019-05-15 | 2019-05-28 | 36 | 0d |
| 38 | 15 | Įjungimo programos patvirtinimas (1-2 d.d.) |  | 2d | 2019-05-29 | 2019-05-30 | 37 | 0d |
| 39 | 16 | Įjungimo programa parengta | milestone | 0d | 2019-05-30 | 2019-05-30 | 38 | 0d |
| 40 | 17 | Operatyvinio personalo mokymai (1 d.d.) |  | 1d | 2019-05-31 | 2019-05-31 | 39 | 0d |
| 41 | 18 | Techninė įvertinimo komisija (1 d.d.) |  | 1d | 2019-06-03 | 2019-06-03 | 40 | 0d |
| 42 | 19 | Trūkumų šalinimas po TĮK (Rangovas) |  | 5d | 2019-06-04 | 2019-06-10 | 41 | 0d |
| 43 | 20 | Įrenginių įjungimas pagal patvirtintą įjungimo programą (tik darbo dieną darbo laiku) (1-2 d.d.) |  | 2d | 2019-06-11 | 2019-06-12 | 30FF, 42 | 0d |
| 44 | 21 | Bandomoji eksploatacija (24 val. linijoms, 72 val. pastotės įrenginiams) |  | 3d | 2019-06-13 | 2019-06-17 | 43 | 0d |
| 45 | 22 | Projekto tarpinis etapas baigtas | milestone | 0d | 2019-06-17 | 2019-06-17 | 44 | 0d |
| 46 | 23 | Sekančio etapo rangos darbai |  | 1d | 2019-06-18 | 2019-06-18 | 45 | 0d |
